# 4.4

Schedule from MS Project, 2011-12-05 to 2012-07-03.

## Calendars

- Standard: Mon-Fri 08:00-12:00, 13:00-17:00; Sat-Sun off.

## Resources

| Resource | Rate |
| --- | --- |
| Concrete contractor | 100 |
| Finish carpentry contractor | 90 |
| Fencing contractor | 90 |
| Masonry contractor | 100 |
| General contractor | 120 |
| Architect | 150 |
| Owner |  |
| Mortgage lender |  |
| Inspector | 120 |
| Electric company | 90 |
| Site excavation contractor | 100 |
| Electric contractor | 100 |
| Plumbing contractor | 100 |
| Framing contractor | 100 |
| Roofing contractor | 90 |
| Heating and AC contractor | 100 |
| Insulation contractor | 90 |
| Drywall contractor | 90 |
| Painting contractor | 90 |
| Flooring contractor | 90 |
| Appliance contractor | 100 |
| Landscape contractor | 90 |
| Maid service | 50 |
| Excavation equipment | 50 |
| Concreting equipment | 50 |
| Finishing equipments | 40 |
| Landscaping equipments | 40 |
| Pumps | 40 |
| Brick | 6500 |
| Concrete | 10500 |
| Electric materials 1 | 6000 |
| Electric Materials 2 | 3000 |
| HVAC Materials 1 | 8000 |
| HVAC Materials 2 | 3500 |
| Wood | 7000 |
| Paints | 7500 |
| Tiles | 14000 |
| Insulation | 5500 |
| Appliances Type 1 | 9500 |
| Appliances Type 2 | 14000 |
| Appliances Type 3 | 6000 |
| Architect Site Visit |  |
| Workers training |  |

## Schedule

| ID | WBS | Task | Type | Duration | Start | Finish | Predecessors | Total slack |
| --- | --- | --- | --- | --- | --- | --- | --- | --- |
| 1 | 1 | **Single Family House - Architect Design (3,000 square feet with full basement)** |  | 152d | 2011-12-05 | 2012-07-03 |  | 0d |
| 2 | 1.1 | **General Conditions** |  | 21d | 2011-12-05 | 2012-01-02 |  | 0d |
| 3 | 1.1.1 | Finalize plans and develop estimate with owner, architect |  | 20d | 2011-12-05 | 2011-12-30 |  | 0d |
| 4 | 1.1.2 | Sign contract and notice to proceed |  | 1d | 2012-01-02 | 2012-01-02 | 3 | 0d |
| 5 | 1.1.3 | **Apply for Permits** |  | 0d | 2012-01-02 | 2012-01-02 |  | 0d |
| 6 | 1.1.3.1 | Secure foundation permit | milestone | 0d | 2012-01-02 | 2012-01-02 | 4 | 0d |
| 7 | 1.1.3.2 | Secure framing permit | milestone | 0d | 2012-01-02 | 2012-01-02 | 4 | 0d |
| 8 | 1.1.3.3 | Secure electrical permit | milestone | 0d | 2012-01-02 | 2012-01-02 | 4 | 0d |
| 9 | 1.1.3.4 | Secure plumbing permit | milestone | 0d | 2012-01-02 | 2012-01-02 | 4 | 0d |
| 10 | 1.1.3.5 | Secure HVAC permit | milestone | 0d | 2012-01-02 | 2012-01-02 | 4 | 0d |
| 11 | 1.1.3.6 | Secure miscellaneous permits | milestone | 0d | 2012-01-02 | 2012-01-02 | 4 | 0d |
| 12 | 1.2 | **Site Work** |  | 3d | 2012-01-03 | 2012-01-05 |  | 0d |
| 13 | 1.2.1 | Clear and grub lot |  | 1d | 2012-01-03 | 2012-01-03 | 6, 7, 8, 9, 11, 10 | 0d |
| 14 | 1.2.2 | Install temporary power service |  | 1d | 2012-01-04 | 2012-01-04 | 13 | 0d |
| 15 | 1.2.3 | Install underground utilities |  | 1d | 2012-01-05 | 2012-01-05 | 14 | 0d |
| 16 | 1.3 | **Foundation** |  | 42d | 2012-01-06 | 2012-03-05 |  | 0d |
| 17 | 1.3.1 | Excavate for foundations |  | 3d | 2012-01-06 | 2012-01-10 | 15 | 0d |
| 18 | 1.3.2 | Form basement walls |  | 13d | 2012-01-11 | 2012-01-27 | 17 | 0d |
| 19 | 1.3.3 | Place concrete for foundations & basement walls |  | 12d | 2012-01-30 | 2012-02-14 | 18 | 0d |
| 20 | 1.3.4 | Cure basement walls for 7 days |  | 7d | 2012-02-15 | 2012-02-23 | 19 | 0d |
| 21 | 1.3.5 | Strip basement wall forms |  | 2d | 2012-02-24 | 2012-02-27 | 20 | 0d |
| 22 | 1.3.6 | Waterproof/insulate basement walls |  | 2d | 2012-02-28 | 2012-02-29 | 21 | 0d |
| 23 | 1.3.7 | Perform foundation inspection |  | 1d | 2012-03-01 | 2012-03-01 | 22, 17 | 0d |
| 24 | 1.3.8 | Backfill foundation |  | 2d | 2012-03-02 | 2012-03-05 | 23 | 0d |

| ID | WBS | Task | Duration | Start | Finish | Predecessors | Total slack | Free slack |
| --- | --- | --- | --- | --- | --- | --- | --- | --- |
| 25 | 1.4 | **Framing** | 22d | 2012-03-06 | 2012-04-04 |  | 0d |  |
| 26 | 1.4.1 | Install 1st floor joists | 2d | 2012-03-06 | 2012-03-07 | 24 | 0d |  |
| 27 | 1.4.2 | Lay 1st floor decking | 2d | 2012-03-08 | 2012-03-09 | 26 | 0d |  |
| 28 | 1.4.3 | Frame 1st floor walls | 4d | 2012-03-12 | 2012-03-15 | 27 | 0d |  |
| 29 | 1.4.4 | Frame 1st floor corners | 1d | 2012-03-16 | 2012-03-16 | 28 | 0d |  |
| 30 | 1.4.5 | Install 2nd floor joists | 2d | 2012-03-19 | 2012-03-20 | 29 | 0d |  |
| 31 | 1.4.6 | Frame 2nd floor decking | 2d | 2012-03-21 | 2012-03-22 | 30 | 0d |  |
| 32 | 1.4.7 | Frame 2nd floor walls | 3d | 2012-03-23 | 2012-03-27 | 31 | 0d |  |
| 33 | 1.4.8 | Frame 2nd floor corners | 2d | 2012-03-28 | 2012-03-29 | 32 | 0d |  |
| 34 | 1.4.9 | Complete roof framing | 3d | 2012-03-30 | 2012-04-03 | 33 | 0d |  |
| 35 | 1.4.10 | Conduct framing inspection | 1d | 2012-04-04 | 2012-04-04 | 34 | 0d |  |
| 36 | 1.5 | **Dry In** | 22d | 2012-04-04 | 2012-05-03 |  | 0d |  |
| 37 | 1.5.1 | Install 1st floor sheathing | 3d | 2012-04-05 | 2012-04-09 | 35 | 0d |  |
| 38 | 1.5.2 | Install 2nd floor sheathing | 3d | 2012-04-10 | 2012-04-12 | 37 | 0d |  |
| 39 | 1.5.3 | Install roof decking | 3d | 2012-04-04 | 2012-04-06 | 34 | 4d | 0d |
| 40 | 1.5.4 | Install felt, flashing and shingles | 3d | 2012-04-20 | 2012-04-24 | 48 | 0d |  |
| 41 | 1.5.5 | Hang 1st floor exterior doors | 1d | 2012-04-25 | 2012-04-25 | 40 | 0d |  |
| 42 | 1.5.6 | Install 1st floor windows | 3d | 2012-04-26 | 2012-04-30 | 41 | 0d |  |
| 43 | 1.5.7 | Install 2nd floor windows | 3d | 2012-05-01 | 2012-05-03 | 42 | 0d |  |
| 44 | 1.6 | **Exterior Finishes** | 19d | 2012-05-04 | 2012-05-30 |  | 5d |  |
| 45 | 1.6.1 | Complete exterior brick | 16d | 2012-05-04 | 2012-05-25 | 43 | 5d | 0d |
| 46 | 1.6.2 | Complete exterior siding | 3d | 2012-05-28 | 2012-05-30 | 45 | 5d | 0d |
| 47 | 1.7 | **Utility Rough-B97Ins and Complete Concrete** | 21d | 2012-04-09 | 2012-05-07 |  | 4d |  |
| 48 | 1.7.1 | Rough-in plumbing | 5d | 2012-04-13 | 2012-04-19 | 39, 38 | 0d |  |
| 49 | 1.7.2 | Conduct rough-in plumbing inspection | 1d | 2012-04-20 | 2012-04-20 | 48 | 20d | 0d |
| 50 | 1.7.3 | Place concrete for basement floor | 11d | 2012-04-23 | 2012-05-07 | 49 | 33d |  |
| 51 | 1.7.4 | Rough-in electrical | 5d | 2012-04-13 | 2012-04-19 | 39, 38 | 6d | 0d |
| 52 | 1.7.5 | Conduct rough-in electrical inspection | 1d | 2012-04-20 | 2012-04-20 | 51 | 6d | 0d |
| 53 | 1.7.6 | Rough-in HVAC | 3d | 2012-04-23 | 2012-04-25 | 52 | 6d | 0d |
| 54 | 1.7.7 | Conduct rough-in HVAC inspection | 1d | 2012-04-26 | 2012-04-26 | 53 | 24d |  |
| 55 | 1.7.8 | Rough-in communication - phone, cable, computer, alarm | 2d | 2012-04-09 | 2012-04-10 | 39 | 17d |  |

| ID | WBS | Task | Duration | Start | Finish | Predecessors | Total slack | Free slack |
| --- | --- | --- | --- | --- | --- | --- | --- | --- |
| 56 | 1.8 | **Interior Finishes** | 43d | 2012-05-04 | 2012-07-03 |  | 0d |  |
| 57 | 1.8.1 | **Insulation** | 11d | 2012-05-04 | 2012-05-18 |  | 0d |  |
| 58 | 1.8.1.1 | Place wall insulation - 1st floor | 1d | 2012-05-04 | 2012-05-04 | 37, 43, 55, 53, 51, 38 | 0d |  |
| 59 | 1.8.1.2 | Place wall insulation - 2nd floor | 1d | 2012-05-07 | 2012-05-07 | 58 | 27d | 3d |
| 60 | 1.8.1.3 | Place ceiling insulation - 2nd floor | 1d | 2012-05-17 | 2012-05-17 | 66, 59 | 24d | 0d |
| 61 | 1.8.1.4 | Conduct insulation inspection | 1d | 2012-05-18 | 2012-05-18 | 60 | 24d |  |
| 62 | 1.8.2 | **Drywall** | 9d | 2012-05-07 | 2012-05-17 |  | 0d |  |
| 63 | 1.8.2.1 | Install drywall - 1st floor walls | 2d | 2012-05-07 | 2012-05-08 | 58 | 0d |  |
| 64 | 1.8.2.2 | Install drywall - 1st floor overhead | 2d | 2012-05-09 | 2012-05-10 | 63 | 0d |  |
| 65 | 1.8.2.3 | Install drywall 2nd floor walls | 2d | 2012-05-11 | 2012-05-14 | 64, 59 | 24d | 0d |
| 66 | 1.8.2.4 | Install drywall 2nd floor overhead | 2d | 2012-05-15 | 2012-05-16 | 65 | 24d | 0d |
| 67 | 1.8.2.5 | Tape and float 1st floor drywall | 1d | 2012-05-11 | 2012-05-11 | 64 | 0d |  |
| 68 | 1.8.2.6 | Tape and float 2nd floor drywall | 1d | 2012-05-17 | 2012-05-17 | 66, 67 | 33d |  |
| 69 | 1.8.3 | **Paint and Wallpaper** | 17d | 2012-05-14 | 2012-06-05 |  | 0d |  |
| 70 | 1.8.3.1 | Texture all except entry and kitchen - 1st floor | 1d | 2012-05-14 | 2012-05-14 | 67 | 0d |  |
| 71 | 1.8.3.2 | Paint all except entry and kitchen - 1st floor | 1d | 2012-05-15 | 2012-05-15 | 70 | 0d |  |
| 72 | 1.8.3.3 | Hang wallpaper entry and kitchen - 1st floor | 1d | 2012-05-16 | 2012-05-16 | 71 | 0d |  |
| 73 | 1.8.3.4 | Texture all - 2nd floor | 1d | 2012-05-15 | 2012-05-15 | 70 | 34d | 0d |
| 74 | 1.8.3.5 | Paint all - 2nd floor | 1d | 2012-05-16 | 2012-05-16 | 73 | 34d |  |
| 75 | 1.8.3.6 | Paint exterior siding & trim work | 4d | 2012-05-31 | 2012-06-05 | 46 | 5d | 0d |
| 76 | 1.8.4 | **Cabinets** | 6d | 2012-05-17 | 2012-05-24 |  | 0d |  |
| 77 | 1.8.4.1 | Install 1st floor - kitchen cabinets | 2d | 2012-05-17 | 2012-05-18 | 72 | 0d |  |
| 78 | 1.8.4.2 | Install 1st floor - master bath and guest cabinets | 1d | 2012-05-21 | 2012-05-21 | 77 | 0d |  |
| 79 | 1.8.4.3 | Install 2nd floor - hall bath and private bath cabinets | 1d | 2012-05-22 | 2012-05-22 | 78 | 1d | 0d |
| 80 | 1.8.4.4 | Install chair rails, crown moldings, trim | 2d | 2012-05-23 | 2012-05-24 | 79 | 20d |  |

| ID | WBS | Task | Duration | Start | Finish | Predecessors | Total slack | Free slack |
| --- | --- | --- | --- | --- | --- | --- | --- | --- |
| 81 | 1.8.5 | **Finish Plumbing** | 6d | 2012-05-21 | 2012-05-28 |  | 0d |  |
| 82 | 1.8.5.1 | Complete 1st floor - kitchen plumbing | 1d | 2012-05-21 | 2012-05-21 | 77, 49 | 0d |  |
| 83 | 1.8.5.2 | Complete 1st floor - master bath and guest plumbing | 2d | 2012-05-22 | 2012-05-23 | 82, 78 | 0d |  |
| 84 | 1.8.5.3 | Compl ete 2nd floor - hall bath and private bath plumbing | 2d | 2012-05-24 | 2012-05-25 | 83, 79 | 0d |  |
| 85 | 1.8.5.4 | Conduct finish plumbing inspection | 1d | 2012-05-28 | 2012-05-28 | 84 | 0d |  |
| 86 | 1.8.6 | **Finish Electrical** | 3d | 2012-05-28 | 2012-05-30 |  | 1d |  |
| 87 | 1.8.6.1 | Complete 1st floor circuits to service panel | 1d | 2012-05-28 | 2012-05-28 | 84, 52 | 3d | 0d |
| 88 | 1.8.6.2 | Complete 2nd floor circuits to service panel | 1d | 2012-05-29 | 2012-05-29 | 87 | 3d | 0d |
| 89 | 1.8.6.3 | Conduct finish electrical inspection | 1d | 2012-05-30 | 2012-05-30 | 88 | 3d |  |
| 90 | 1.8.6.4 | Complete communications wiring - phone, cable, computer, alarm | 2d | 2012-05-29 | 2012-05-30 | 85 | 0d |  |
| 91 | 1.8.7 | **Finish HVAC** | 3d | 2012-05-31 | 2012-06-04 |  | 0d |  |
| 92 | 1.8.7.1 | Complete 1st floor - zone 1 HVAC | 1d | 2012-05-31 | 2012-05-31 | 90, 54 | 0d |  |
| 93 | 1.8.7.2 | Complete 2nd floor - zone 2 HVAC | 1d | 2012-06-01 | 2012-06-01 | 92 | 0d |  |
| 94 | 1.8.7.3 | Conduct HVAC inspection | 1d | 2012-06-04 | 2012-06-04 | 93 | 0d |  |
| 95 | 1.8.8 | **Carpet, Tile and Appliances** | 8d | 2012-06-05 | 2012-06-14 |  | 0d |  |
| 96 | 1.8.8.1 | Tile entry, kitchen and baths | 3d | 2012-06-05 | 2012-06-07 | 89, 94 | 0d |  |
| 97 | 1.8.8.2 | Carpet 1st floor | 2d | 2012-06-08 | 2012-06-11 | 96 | 0d |  |
| 98 | 1.8.8.3 | Carpet 2nd floor | 2d | 2012-06-12 | 2012-06-13 | 97 | 0d |  |
| 99 | 1.8.8.4 | Install appliances | 1d | 2012-06-14 | 2012-06-14 | 98 | 0d |  |
| 100 | 1.8.9 | **Landscaping and Grounds Work** | 12d | 2012-06-06 | 2012-06-21 |  | 0d |  |
| 101 | 1.8.9.1 | Pour concrete driveway and sidewalks | 2d | 2012-06-06 | 2012-06-07 | 75 | 5d |  |
| 102 | 1.8.9.2 | Install backyard fence | 2d | 2012-06-15 | 2012-06-18 | 99, 101 | 0d |  |
| 103 | 1.8.9.3 | Sod and complete plantings - front yard | 2d | 2012-06-19 | 2012-06-20 | 102 | 0d |  |
| 104 | 1.8.9.4 | Sod and complete plantings - backyard | 1d | 2012-06-21 | 2012-06-21 | 103 | 0d |  |

| ID | WBS | Task | Duration | Start | Finish | Predecessors | Total slack |
| --- | --- | --- | --- | --- | --- | --- | --- |
| 105 | 1.8.10 | **Final Acceptance** | 8d | 2012-06-22 | 2012-07-03 |  | 0d |
| 106 | 1.8.10.1 | Complete final inspection for certificate of occupancy | 1d | 2012-06-22 | 2012-06-22 | 104, 94, 89, 85, 61, 80, 50 | 0d |
| 107 | 1.8.10.2 | Cleanup for occupancy | 1d | 2012-06-25 | 2012-06-25 | 99, 106 | 0d |
| 108 | 1.8.10.3 | Perform final walk-through inspection | 1d | 2012-06-26 | 2012-06-26 | 107 | 0d |
| 109 | 1.8.10.4 | Complete punch list items | 5d | 2012-06-27 | 2012-07-03 | 108 | 0d |
